# SITIO 4 ALTERNATIVA 1

Schedule from MS Project, 2017-01-02 to 2017-08-05.
Hewlett-Packard Company

## Calendars

- Standard: Mon-Sun 08:00-12:00, 13:00-17:00.

## Resources

| Resource |
| --- |
| Gerente |
| Vehiculos |
| Madera |
| Carpinteros |
| Albañiles |
| Camion de Estaca |
| Pickup |
| Capataz |
| Auxiliares |
| Piochas |
| Palas |
| Machetes |
| Ing. Control de Calidad |
| Auxiliar |
| Albañil |
| Lic. en gestión social |
| Motorista de cabezales |
| Motorista de camión y pipas |
| Motorista de pick-up |
| Operador clase 1.00 (motn; grua;d8) |
| Operador clase 2 (trac; carmix; rodos) |
| Operador clase 3 (minic;retro;load) |
| Operador de equipos livianos |
| Eléctrico |
| Bodeguero |
| Topógrafo |
| Primer cadenero |
| Segundo cadenero |
| Marrero |
| Carpintero |
| Armador |
| Mecánico |
| Jardinero |
| Mobiliario Oficina |
| Laminas Galvanizada |
| Cabezal Y lowboy |
| Camión de Volteo |
| Retroexcavadora |
| Pala Mecánica |
| Tractor |
| Motoniveladora |
| Rodo Vibratorio |
| Perforadora p/SOIL NAIL |
| Bomba y Accesorios p/concreto |
| Estación Total |
| Nivel Fijo |
| Prismas |
| Ing. Superintendente |
| Laboratorista |
| Rodo Vibratorio Pequeño |
| Bailarina Mecánica |
| Acero de Refuerzo |
| Moldes |
| Concreto |
| Herramiento Menor |
| Concreto p/Anclajes |
| Material Selecto |
| Cemento |
| Lodocreto |
| Equipo Postensado |
| Elementos de Señalización |
| Banderolas |
| Pantalla Electronica |
| Uniformes |
| Arboles para Siembra |
| Tierra Negra |
| Grama |
| Zacate Vetiver |
| Equipo de Laboratorio |
| Operador de equipo Terracería |
| Camión Cisterna |
| Grava |
| Arena |
| Piedra |
| Concretera |
| Fresadora |
| Minicargador |
| Cargador Frontal |
| Pavimentadora |
| Distribuidor Asfalto |
| Barredora |
| Sopladora |
| Rastrilleros |
| Mezcla Asfáltica |
| Emulsión Asfáltica |
| Rodo Neumático |

## Schedule

| ID | WBS | Task | Type | Duration | Start | Finish | Predecessors | Total slack | Free slack |
| --- | --- | --- | --- | --- | --- | --- | --- | --- | --- |
| 1 | 1 | **REFORZAR LA MALLA EXISTENTE Y BARRERA PARA ESPRENDIMIENTOS** |  | 216d | 2017-01-02 | 2017-08-05 |  | 0d |  |
| 2 | 1.1 | INICIO | milestone | 0d | 2017-01-02 | 2017-01-02 |  | 0d |  |
| 3 | 1.2 | MOVILIZACION |  | 10d | 2017-01-02 | 2017-01-11 | 2 | 0d |  |
| 4 | 1.3 | INSTALACIONES PROVISIONALES |  | 9d | 2017-01-02 | 2017-01-10 | 2 | 1d |  |
| 5 | 1.4 | MOVILIZACION DE MAQUINARIA |  | 9d | 2017-01-02 | 2017-01-10 | 2 | 1d |  |
| 6 | 1.5 | TRAZO |  | 6d | 2017-01-02 | 2017-01-07 | 2 | 35d | 0d |
| 7 | 1.6 | DESALOJO DE ROCAS |  | 20d | 2017-01-08 | 2017-01-27 | 6 | 9d |  |
| 8 | 1.7 | ELIMINACION DE ROCAS SUELTAS |  | 25d | 2017-01-12 | 2017-02-05 | 3, 4, 5 | 0d |  |
| 9 | 1.8 | COLOCACION DE ANCLAJES EN MALLAS |  | 15d | 2017-02-06 | 2017-02-20 | 8 | 5d | 0d |
| 10 | 1.9 | COLOCACION DE ANCLAJES EN CABLES |  | 15d | 2017-02-21 | 2017-03-07 | 9 | 5d |  |
| 11 | 1.10 | ELIMINACION DE VEGETACION |  | 15d | 2017-02-06 | 2017-02-20 | 8, 7 | 0d |  |
| 12 | 1.11 | COLOCACION DE ANCLAJES CABLE SUPERIOR |  | 10d | 2017-02-21 | 2017-03-02 | 11 | 2d | 0d |
| 13 | 1.12 | COLOCACION DE CABLE SUPERIOR |  | 8d | 2017-03-03 | 2017-03-10 | 12 | 2d |  |
| 14 | 1.13 | PERFILADO DE ROCA |  | 20d | 2017-02-21 | 2017-03-12 | 11 | 0d |  |
| 15 | 1.14 | COLOCACION DE ANCLAJES EN MALLAS |  | 15d | 2017-03-13 | 2017-03-27 | 14 | 30d | 0d |
| 16 | 1.15 | COLOCACION DE ANCLAJES EN CABLES |  | 15d | 2017-03-28 | 2017-04-11 | 15 | 30d |  |
| 17 | 1.16 | COLOCACION DE MALLA |  | 40d | 2017-03-13 | 2017-04-21 | 14, 13, 10 | 0d |  |
| 18 | 1.17 | SUJECION ANCLAJES |  | 40d | 2017-03-13 | 2017-04-21 | 14 | 20d |  |
| 19 | 1.18 | COLOCACION DE RED DE CABLES |  | 20d | 2017-04-22 | 2017-05-11 | 17 | 0d |  |
| 20 | 1.19 | CONSTRUCCION DE MURO DE CONCRETO |  | 50d | 2017-05-12 | 2017-06-30 | 19, 18, 16 | 0d |  |
| 21 | 1.20 | COLOCACION DE BARRERA DINAMICA |  | 30d | 2017-07-01 | 2017-07-30 | 20 | 0d |  |
| 22 | 1.21 | ASPECTOS DE SEGURIDAD |  | 190d | 2017-01-02 | 2017-07-10 | 2 | 26d |  |
| 23 | 1.22 | ASPECTOS AMBIENTALES |  | 190d | 2017-01-02 | 2017-07-10 | 2 | 26d |  |
| 24 | 1.23 | CONTROL DE CALIDAD |  | 190d | 2017-01-02 | 2017-07-10 | 2 | 26d |  |
| 25 | 1.24 | DESALOJO |  | 6d | 2017-07-31 | 2017-08-05 | 21 | 0d |  |
| 26 | 1.25 | ENTREGA | milestone | 0d | 2017-08-05 | 2017-08-05 | 25, 22, 23, 24 | 0d |  |
